# Фильм

Schedule from MS Project, 2022-10-10 to 2023-02-03, status date 2023-01-02, costs in р., A marks actual dates.
Microsoft

## Calendars

- Стандартный: Mon-Fri 09:00-13:00, 14:00-18:00; Sat-Sun off.

## Resources

| Resource | Unit | Rate |
| --- | --- | --- |
| Режиссер |  | 1000 |
| Продюсер |  | 1500 |
| Актеры |  | 500 |
| Гример |  | 300 |
| Костюмер |  | 300 |
| Камера |  |  |
| Карта памяти | шт | 5000 |
| Бизнес-ланч | шт | 500 |
| Оплата сценария |  |  |
| Оператор |  | 750 |
| Монтажер |  | 750 |

## Schedule

| ID | WBS | Task | Type | Duration | Start | Finish | Predecessors | Complete | Baseline start | Baseline finish | Baseline duration | Total slack | Constraint | Resources | Work | Actual work | Cost | Baseline cost | Actual cost |
| --- | --- | --- | --- | --- | --- | --- | --- | --- | --- | --- | --- | --- | --- | --- | --- | --- | --- | --- | --- |
| 1 | 1 | **Подготовительный этап** |  | 30d | 2022-10-10 A | 2022-11-18 A |  | 100% | 2022-10-10 | 2022-10-31 | 16d |  |  |  | 1220h | 1220h | 800,000 | 642,000 | 800,000 |
| 2 | 1.1 | Разработка сценария |  | 3d | 2022-10-10 A | 2022-10-12 A |  | 100% | 2022-10-10 | 2022-10-12 | 3d |  |  | Оплата сценария [0.1%] |  |  | 300,000 | 300,000 | 300,000 |
| 3 | 1.2 | Планирование съемок |  | 3w | 2022-10-13 A | 2022-11-02 A | 2 | 100% | 2022-10-13 | 2022-10-26 | 2w |  |  | Режиссер; Продюсер | 240h | 240h | 300,000 | 200,000 | 300,000 |
| 4 | 1.3 | Выбор натуры |  | 5d | 2022-11-07 A | 2022-11-11 A | 3 | 100% | 2022-10-27 | 2022-10-31 | 3d |  | start no earlier than 2022-11-07 | Режиссер [50%]; Оператор | 60h | 60h | 100,000 | 30,000 | 100,000 |
| 5 | 1.4 | Пробы актеров |  | 10d | 2022-11-07 A | 2022-11-18 A | 3 | 100% | 2022-10-27 | 2022-10-28 | 2d |  | start no earlier than 2022-11-07 | Продюсер; Режиссер [50%]; Актеры [1000%] | 920h | 920h | 100,000 | 112,000 | 100,000 |
| 6 | 1.5 | Подготовительный этап закончен | milestone | 0d | 2022-11-18 A | 2022-11-18 A | 5, 4 | 100% | 2022-10-31 | 2022-10-31 | 0d |  |  |  |  |  |  |  |  |
| 7 | 2 | **Запуск в производство** |  | 48d | 2022-11-21 A | 2023-01-25 A | 1 | 100% | 2022-11-01 | 2022-11-28 | 20d |  |  |  | 6876h | 6876h | 2,530,000 | 1,299,500 | 2,530,000 |
| 8 | 2.1 | Репетиция |  | 3w | 2022-11-21 A | 2022-12-09 A |  | 100% | 2022-11-01 | 2022-11-07 | 1w |  |  | Актеры [1000%]; Бизнес-ланч [1.88 шт]; Гример; Камера [300%]; Карта памяти [0.12 шт]; Костюмер; Оператор [300%]; Режиссер | 2280h | 2280h | 1,000,000 | 416,500 | 1,000,000 |
| 9 | 2.2 | Съемки |  | 1.5mo | 2022-12-12 A | 2023-01-20 A | 8 | 100% | 2022-11-08 | 2022-11-21 | 2w |  |  | Актеры [1000%]; Бизнес-ланч [1.88 шт]; Гример; Камера [300%]; Карта памяти [0.12 шт]; Костюмер; Оператор [300%]; Режиссер | 4560h | 4560h | 1,500,000 | 833,000 | 1,500,000 |
| 10 | 2.3 | Монтаж отснятого материала |  | 3d | 2023-01-23 A | 2023-01-25 A | 9 | 100% | 2022-11-22 | 2022-11-28 | 1w |  |  | Монтажер; Режиссер [50%] | 36h | 36h | 30,000 | 50,000 | 30,000 |
| 11 | 2.4 | Производство завершено | milestone | 0d | 2023-01-25 A | 2023-01-25 A | 10 | 100% | 2022-11-28 | 2022-11-28 | 0d |  |  |  |  |  |  |  |  |
| 12 | 3 | **Завершающий этап** |  | 7d | 2023-01-26 | 2023-02-03 | 7 |  | 2022-11-29 | 2022-12-05 | 5d | 0d |  |  | 252h |  | 174,000 | 152,000 |  |
| 13 | 3.1 | Окончательная обработка |  | 5d | 2023-01-26 | 2023-02-01 |  |  | 2022-11-29 | 2022-12-01 | 3d | 0d |  | Режиссер; Продюсер [50%]; Оператор; Монтажер | 140h |  | 100,000 | 78,000 |  |
| 14 | 3.2 | Озвучивание |  | 1d | 2023-02-02 | 2023-02-02 | 13 |  | 2022-12-02 | 2022-12-02 | 1d | 0d |  | Режиссер; Актеры [1000%]; Монтажер | 96h |  | 54,000 | 54,000 |  |
| 15 | 3.3 | Предоставление материала заказчику |  | 1d | 2023-02-03 | 2023-02-03 | 14 |  | 2022-12-05 | 2022-12-05 | 1d | 0d |  | Продюсер; Режиссер | 16h |  | 20,000 | 20,000 |  |
